# 2011 Support Pack Implementation Project

Schedule from MS Project, 2011-08-29 to 2012-01-27, A marks actual dates.

## Calendars

- Standard: Mon-Fri 08:00-12:00, 13:00-17:00; Sat-Sun off.
- 24 Hours: Mon-Sun 00:00-24:00.

## Resources

| Resource |
| --- |
| ERP Manager |
| PM |
| Team Lead |
| Testing Coordinator |
| R3 |
| TC |
| Transport Coordinator |
| Testing Coordinator - HR |
| Testing Coordinator - FI |
| TranC |
| TransC |
| TestC - HR |
| TestC - FI |
| TestC-HR |
| TestC-FI |
| Team Lead-HR |
| Team Lead-FI |
| IDD |
| QA |
| ABAP Lead |
| BA1 |
| DW |
| R3-1 |
| R3-2 |
| R3-3 |
| ABAP |
| FIN |
| log |
| EHS |
| HRP |
| Bus |
| SAP |
| Core |
| All |
| BC |
| IST-SAP |
| R3-4 |
| QA-4 |
| Bus-Val |
| FIN-1 |
| LOG-1 |
| EHS-1 |
| FIN-Team |
| Log-Team |
| EHS-Team |
| HRP-Team |
| OIS |
| OPS |
| SO |

## Schedule

| ID | WBS | Task | Duration | Start | Finish | Predecessors | Complete | Remaining | Total slack | Free slack | Resources | Work | Actual work |
| --- | --- | --- | --- | --- | --- | --- | --- | --- | --- | --- | --- | --- | --- |
| 1 | 1 | **Project Preparation & Planning** | 63d | 2011-08-29 08:00 A | 2011-11-23 17:00 |  | 93% | 4.46d | 46.12d |  |  | 297h | 278h |
| 2 | 1.1 | **Appoint project team, define roles and responsibilities** | 9.12d | 2011-08-29 08:00 A | 2011-09-09 09:00 A |  | 100% |  |  |  |  | 73h | 73h |
| 3 | 1.1.1 | Appoint project manager | 1h | 2011-08-29 08:00 A | 2011-08-29 09:00 A |  | 100% |  |  |  | ERP Manager | 1h | 1h |
| 4 | 1.1.2 | Define project team, member roles and responsibilities | 1d | 2011-08-30 09:00 A | 2011-08-31 09:00 A | 3FS+1d | 100% |  |  |  | PM | 8h | 8h |
| 5 | 1.1.3 | Appoint project team members (core team/testing coordinators/extended team, etc …) | 3d | 2011-08-31 09:00 A | 2011-09-05 09:00 A | 4 | 100% |  |  |  | PM | 24h | 24h |
| 6 | 1.1.4 | Notify project team members of their role | 1d | 2011-09-06 09:00 A | 2011-09-07 09:00 A | 5FS+1d | 100% |  |  |  | PM; Team Lead-HR; Team Lead-FI | 24h | 24h |
| 7 | 1.1.5 | Update business owner list with new / changed owners | 1d | 2011-09-08 09:00 A | 2011-09-09 09:00 A | 6FS+1d | 100% |  |  |  | TestC-FI; TestC-HR | 16h | 16h |
| 8 | 1.2 | **Develop Project Plan** | 19.21d | 2011-08-29 09:00 A | 2011-09-23 10:40 A | 3 | 100% |  |  |  |  | 112h | 112h |
| 9 | 1.2.1 | Determine support package availability date | 1d | 2011-08-29 09:00 A | 2011-08-30 09:00 A |  | 100% |  |  |  | PM | 8h | 8h |
| 10 | 1.2.2 | Determine desired support package & enhancement package levels | 1d | 2011-08-30 09:00 A | 2011-08-31 09:00 A | 9 | 100% |  |  |  | PM | 8h | 8h |
| 11 | 1.2.3 | Determine dates for production freeze | 1d | 2011-09-07 10:40 A | 2011-09-08 10:40 A | 15 | 100% |  |  |  | PM | 8h | 8h |
| 12 | 1.2.4 | Define high level plan, milestones, deliverables | 5d | 2011-09-08 10:40 A | 2011-09-15 10:40 A | 11 | 100% |  |  |  | PM | 40h | 40h |
| 13 | 1.2.5 | Identify Pending Projects that may collide with the project | 1d | 2011-09-15 10:40 A | 2011-09-16 10:40 A | 12 | 100% |  |  |  | PM | 8h | 8h |
| 14 | 1.2.6 | Review any development/cleanup work that can be included in the project | 5d | 2011-09-16 10:40 A | 2011-09-23 10:40 A | 13 | 100% |  |  |  | BC | 40h | 40h |
| 15 | 1.3 | **Define environments, refresh schedule, support pack plan** | 2.21d | 2011-09-05 09:00 A | 2011-09-07 10:40 A |  | 100% |  |  |  |  | 9h | 9h |
| 16 | 1.3.1 | Identify environments for Staging, and TST (DEV not refreshed) | 1h | 2011-09-05 09:00 A | 2011-09-05 10:00 A | 5 | 100% |  |  |  | R3; PM | 2h | 2h |
| 17 | 1.3.2 | Develop/update env landscape document | 1h | 2011-09-05 10:00 A | 2011-09-05 11:00 A | 16 | 100% |  |  |  | PM | 1h | 1h |
| 18 | 1.3.3 | Determine production snapshot dates for STG, TST | 1h | 2011-09-07 09:00 A | 2011-09-07 10:00 A | 6 | 100% |  |  |  | TestC-FI; TestC-HR | 2h | 2h |
| 19 | 1.3.4 | Determine dates for STG, TST refreshes | 1h | 2011-09-07 09:00 A | 2011-09-07 10:00 A | 6 | 100% |  |  |  | R3; PM | 2h | 2h |
| 20 | 1.3.5 | Plan datawarehouse extracts | 0.67h | 2011-09-07 10:00 A | 2011-09-07 10:40 A | 19 | 100% |  |  |  | R3; PM; DW | 2h | 2h |
| 21 | 1.4 | **Develop cut-over plan** | 19d | 2011-10-28 08:00 A | 2011-11-23 17:00 | 204 | 82% | 3.5d | 46.12d |  |  | 103h | 84h |
| 22 | 1.4.1 | Identify resources | 1d | 2011-10-28 08:00 A | 2011-10-28 17:00 A |  | 100% |  |  |  | PM | 8h | 8h |
| 23 | 1.4.2 | Prep cut-over plan document | 4h | 2011-10-28 08:00 A | 2011-10-28 12:00 A |  | 100% |  |  |  | PM | 4h | 4h |
| 24 | 1.4.3 | Review transports resulting from SPAU | 4h | 2011-10-28 08:00 | 2011-10-28 12:00 |  |  |  | 64.62d |  | Core | 4h |  |
| 25 | 1.4.4 | Review transports resulting from Unit Test | 4h | 2011-11-07 08:00 | 2011-11-07 12:00 | 223 |  |  | 58.25d | 0d | Core | 4h |  |
| 26 | 1.4.5 | Review transports resulting from SIT/UAT | 4h | 2011-11-23 08:00 | 2011-11-23 12:00 | 268 |  |  | 46.12d | 0d | Core | 4h |  |
| 27 | 1.4.6 | Schedule cut-over plan meeting | 1h | 2011-11-07 13:00 | 2011-11-07 14:00 | 25 |  |  | 58.25d | 0d | PM | 1h |  |
| 28 | 1.4.7 | Cut-over plan meeting | 2h | 2011-11-07 14:00 | 2011-11-07 16:00 | 27 |  |  | 58.25d |  | Core | 2h |  |
| 29 | 1.4.8 | Develop cut-over plan & publish | 9d | 2011-11-07 16:00 A | 2011-11-18 16:00 A | 28 | 100% |  |  |  | PM | 72h | 72h |
| 30 | 1.4.9 | Finalize cut-over plan & publish | 4h | 2011-11-23 13:00 | 2011-11-23 17:00 | 26 |  |  | 46.12d |  | Core | 4h |  |

| ID | WBS | Task | Duration | Start | Finish | Predecessors | Complete | Remaining | Total slack | Constraint | Resources | Work | Actual work |
| --- | --- | --- | --- | --- | --- | --- | --- | --- | --- | --- | --- | --- | --- |
| 31 | 2 | **Communication** | 109.12d | 2011-08-29 08:00 A | 2012-01-27 09:00 |  | 81% | 20.79d | 2d |  |  | 262h | 257h |
| 32 | 2.1 | Develop project wiki | 5d | 2011-08-31 09:00 A | 2011-09-07 09:00 A | 3FS+2d | 100% |  |  |  | PM; IDD; QA | 120h | 120h |
| 33 | 2.2 | Schedule IS&T (Admin Systems) project kick-off meeting | 2h | 2011-08-29 08:00 A | 2011-08-29 10:00 A |  | 100% |  |  |  | PM; ERP Manager | 4h | 4h |
| 34 | 2.3 | Schedule SAPbiz project kick-off meeting (last meeting of September) | 1h | 2011-08-31 09:00 A | 2011-08-31 10:00 A | 3FS+2d | 100% |  |  |  | PM | 1h | 1h |
| 35 | 2.4 | Schedule Steering Committee Meeting | 1d | 2011-09-02 09:00 A | 2011-09-05 09:00 A | 3FS+4d | 100% |  |  |  | PM | 8h | 8h |
| 36 | 2.5 | Schedule Core Team Meeting(s) | 1d | 2011-09-08 09:00 A | 2011-09-09 09:00 A | 6FS+1d | 100% |  |  |  | PM | 8h | 8h |
| 37 | 2.6 | Review/update communication email list sap-upgrade-core@mit.edu | 1h | 2011-09-09 09:00 A | 2011-09-09 10:00 A | 7 | 100% |  |  |  | PM | 1h | 1h |
| 38 | 2.7 | Review/update communication email list ist-sap@mit.edu | 1h | 2011-09-09 10:00 A | 2011-09-09 11:00 A | 37 | 100% |  |  |  | PM | 1h | 1h |
| 39 | 2.8 | Prepare Project Presentation for the Steering Committee | 2d | 2011-09-05 09:00 A | 2011-09-07 09:00 A | 35 | 100% |  |  |  | PM | 16h | 16h |
| 40 | 2.9 | Prepare Project Presentation for IS&T | 2d | 2011-09-07 09:00 A | 2011-09-09 09:00 A | 39 | 100% |  |  |  | PM; QA; R3 | 48h | 48h |
| 41 | 2.10 | Prepare Project Presentation for SAPbiz | 2d | 2011-09-09 09:00 A | 2011-09-13 09:00 A | 40 | 100% |  |  |  | PM; QA; R3 | 48h | 48h |
| 42 | 2.11 | IS&T Kick off meeting | 2h | 2011-09-15 10:40 A | 2011-09-15 13:40 A | 12 | 100% |  |  |  | IST-SAP | 2h | 2h |
| 43 | 2.12 | Review/update communication email list sap-vailidation-team@mit.edu | 1h | 2011-11-28 08:00 | 2011-11-28 09:00 | 258SS+15d |  |  | 44d |  | PM; TestC - HR; TestC - FI | 3h |  |
| 44 | 2.13 | **Steering Committee Meeting** | 84.12d | 2011-09-13 08:00 A | 2012-01-09 09:00 |  | 60% | 33.65d | 16d |  |  |  |  |
| 45 | 2.13.1 | Steering Committee Meeting 1 | 1h | 2011-09-13 08:00 A | 2011-09-13 09:00 A |  | 100% |  |  | start no earlier than 2011-09-13 08:00 |  |  |  |
| 46 | 2.13.2 | Steering Committee Meeting 2 | 1h | 2011-10-03 08:00 A | 2011-10-03 09:00 A |  | 100% |  |  | start no earlier than 2011-10-03 08:00 |  |  |  |
| 47 | 2.13.3 | Steering Committee Meeting 3 | 1h | 2011-11-07 08:00 A | 2011-11-07 09:00 A |  | 100% |  |  | start no earlier than 2011-11-07 08:00 |  |  |  |
| 48 | 2.13.4 | Steering Committee Meeting 4 | 1h | 2011-12-05 08:00 | 2011-12-05 09:00 |  |  |  | 41d | start no earlier than 2011-12-05 08:00 |  |  |  |
| 49 | 2.13.5 | Steering Committee Meeting 5 | 1h | 2012-01-09 08:00 | 2012-01-09 09:00 |  |  |  | 16d | start no earlier than 2012-01-09 08:00 |  |  |  |
| 50 | 2.14 | **Core Team Meeting** | 80.12d | 2011-09-12 08:00 A | 2012-01-02 09:00 |  | 59% | 32.99d | 21d |  |  |  |  |
| 51 | 2.14.1 | Core Team Meeting 1 | 1h | 2011-09-12 08:00 A | 2011-09-12 09:00 A |  | 100% |  |  | start no earlier than 2011-09-12 08:00 |  |  |  |
| 52 | 2.14.2 | Core Team Meeting 2 | 1h | 2011-09-19 08:00 A | 2011-09-19 09:00 A |  | 100% |  |  | start no earlier than 2011-09-19 08:00 |  |  |  |
| 53 | 2.14.3 | Core Team Meeting 3 | 1h | 2011-09-26 08:00 A | 2011-09-26 09:00 A |  | 100% |  |  | start no earlier than 2011-09-26 08:00 |  |  |  |
| 54 | 2.14.4 | Core Team Meeting 4 | 1h | 2011-10-03 08:00 A | 2011-10-03 09:00 A |  | 100% |  |  | start no earlier than 2011-10-03 08:00 |  |  |  |
| 55 | 2.14.5 | Core Team Meeting 5 | 1h | 2011-10-10 08:00 A | 2011-10-10 09:00 A |  | 100% |  |  | start no earlier than 2011-10-10 08:00 |  |  |  |
| 56 | 2.14.6 | Core Team Meeting 6 | 1h | 2011-10-17 08:00 A | 2011-10-17 09:00 A |  | 100% |  |  | start no earlier than 2011-10-17 08:00 |  |  |  |
| 57 | 2.14.7 | Core Team Meeting 7 | 1h | 2011-10-24 08:00 A | 2011-10-24 09:00 A |  | 100% |  |  | start no earlier than 2011-10-24 08:00 |  |  |  |
| 58 | 2.14.8 | Core Team Meeting 8 | 1h | 2011-10-31 08:00 A | 2011-10-31 09:00 A |  | 100% |  |  | start no earlier than 2011-10-31 08:00 |  |  |  |
| 59 | 2.14.9 | Core Team Meeting 9 | 1h | 2011-11-07 08:00 A | 2011-11-07 09:00 A |  | 100% |  |  | start no earlier than 2011-11-07 08:00 |  |  |  |
| 60 | 2.14.10 | Core Team Meeting 10 | 1h | 2011-11-14 08:00 A | 2011-11-14 09:00 A |  | 100% |  |  | start no earlier than 2011-11-14 08:00 |  |  |  |
| 61 | 2.14.11 | Core Team Meeting 11 | 1h | 2011-11-21 08:00 | 2011-11-21 09:00 |  |  |  | 51d | start no earlier than 2011-11-21 08:00 |  |  |  |
| 62 | 2.14.12 | Core Team Meeting 12 | 1h | 2011-11-28 08:00 | 2011-11-28 09:00 |  |  |  | 46d | start no earlier than 2011-11-28 08:00 |  |  |  |
| 63 | 2.14.13 | Core Team Meeting 13 | 1h | 2011-12-05 08:00 | 2011-12-05 09:00 |  |  |  | 41d | start no earlier than 2011-12-05 08:00 |  |  |  |
| 64 | 2.14.14 | Core Team Meeting 14 | 1h | 2011-12-12 08:00 | 2011-12-12 09:00 |  |  |  | 36d | start no earlier than 2011-12-12 08:00 |  |  |  |
| 65 | 2.14.15 | Core Team Meeting 15 | 1h | 2011-12-19 08:00 | 2011-12-19 09:00 |  |  |  | 31d | start no earlier than 2011-12-19 08:00 |  |  |  |
| 66 | 2.14.16 | Core Team Meeting 16 | 1h | 2011-12-26 08:00 | 2011-12-26 09:00 |  |  |  | 26d | start no earlier than 2011-12-26 08:00 |  |  |  |
| 67 | 2.14.17 | Core Team Meeting 17 | 1h | 2012-01-02 08:00 | 2012-01-02 09:00 |  |  |  | 21d | start no earlier than 2012-01-02 08:00 |  |  |  |

| ID | WBS | Task | Duration | Start | Finish | Predecessors | Complete | Remaining | Total slack | Constraint | Resources | Work |
| --- | --- | --- | --- | --- | --- | --- | --- | --- | --- | --- | --- | --- |
| 68 | 2.15 | **SAPbiz Meeting** | 95.25d | 2011-09-14 08:00 | 2012-01-25 10:00 |  |  |  | 1.88d |  |  |  |
| 69 | 2.15.1 | SAPbiz Meeting 1 | 2h | 2011-09-14 08:00 | 2011-09-14 10:00 |  |  |  | 98.88d | start no earlier than 2011-09-14 08:00 |  |  |
| 70 | 2.15.2 | SAPbiz Meeting 2 | 2h | 2011-10-26 08:00 | 2011-10-26 10:00 |  |  |  | 68.88d | start no earlier than 2011-10-26 08:00 |  |  |
| 71 | 2.15.3 | SAPbiz Meeting 3 | 2h | 2011-11-23 08:00 | 2011-11-23 10:00 |  |  |  | 48.88d | start no earlier than 2011-11-23 08:00 |  |  |
| 72 | 2.15.4 | SAPbiz Meeting 4 | 2h | 2011-12-21 08:00 | 2011-12-21 10:00 |  |  |  | 28.88d | start no earlier than 2011-12-21 08:00 |  |  |
| 73 | 2.15.5 | SAPbiz Meeting 5 | 2h | 2012-01-25 08:00 | 2012-01-25 10:00 |  |  |  | 3.88d | start no earlier than 2012-01-25 08:00 |  |  |
| 74 | 2.16 | **R3 Admin Meeting** | 105.12d | 2011-09-02 08:00 A | 2012-01-27 09:00 |  | 55% | 47.78d | 2d |  |  |  |
| 75 | 2.16.1 | R3 Admin Meeting 1 | 1h | 2011-09-02 08:00 A | 2011-09-02 09:00 A |  | 100% |  |  | start no earlier than 2011-09-02 08:00 |  |  |
| 76 | 2.16.2 | R3 Admin Meeting 2 | 1h | 2011-09-09 08:00 A | 2011-09-09 09:00 A |  | 100% |  |  | start no earlier than 2011-09-09 08:00 |  |  |
| 77 | 2.16.3 | R3 Admin Meeting 3 | 1h | 2011-09-16 08:00 A | 2011-09-16 09:00 A |  | 100% |  |  | start no earlier than 2011-09-16 08:00 |  |  |
| 78 | 2.16.4 | R3 Admin Meeting 4 | 1h | 2011-09-23 08:00 A | 2011-09-23 09:00 A |  | 100% |  |  | start no earlier than 2011-09-23 08:00 |  |  |
| 79 | 2.16.5 | R3 Admin Meeting 5 | 1h | 2011-09-30 08:00 A | 2011-09-30 09:00 A |  | 100% |  |  | start no earlier than 2011-09-30 08:00 |  |  |
| 80 | 2.16.6 | R3 Admin Meeting 6 | 1h | 2011-10-07 08:00 A | 2011-10-07 09:00 A |  | 100% |  |  | start no earlier than 2011-10-07 08:00 |  |  |
| 81 | 2.16.7 | R3 Admin Meeting 7 | 1h | 2011-10-14 08:00 A | 2011-10-14 09:00 A |  | 100% |  |  | start no earlier than 2011-10-14 08:00 |  |  |
| 82 | 2.16.8 | R3 Admin Meeting 8 | 1h | 2011-10-21 08:00 A | 2011-10-21 09:00 A |  | 100% |  |  | start no earlier than 2011-10-21 08:00 |  |  |
| 83 | 2.16.9 | R3 Admin Meeting 9 | 1h | 2011-10-28 08:00 A | 2011-10-28 09:00 A |  | 100% |  |  | start no earlier than 2011-10-28 08:00 |  |  |
| 84 | 2.16.10 | R3 Admin Meeting 10 | 1h | 2011-11-04 08:00 A | 2011-11-04 09:00 A |  | 100% |  |  | start no earlier than 2011-11-04 08:00 |  |  |
| 85 | 2.16.11 | R3 Admin Meeting 11 | 1h | 2011-11-11 08:00 A | 2011-11-11 09:00 A |  | 100% |  |  | start no earlier than 2011-11-11 08:00 |  |  |
| 86 | 2.16.12 | R3 Admin Meeting 12 | 1h | 2011-11-18 08:00 A | 2011-11-18 09:00 A |  | 100% |  |  | start no earlier than 2011-11-18 08:00 |  |  |
| 87 | 2.16.13 | R3 Admin Meeting 13 | 1h | 2011-11-25 08:00 | 2011-11-25 09:00 |  |  |  | 47d | start no earlier than 2011-11-25 08:00 |  |  |
| 88 | 2.16.14 | R3 Admin Meeting 14 | 1h | 2011-12-02 08:00 | 2011-12-02 09:00 |  |  |  | 42d | start no earlier than 2011-12-02 08:00 |  |  |
| 89 | 2.16.15 | R3 Admin Meeting 15 | 1h | 2011-12-09 08:00 | 2011-12-09 09:00 |  |  |  | 37d | start no earlier than 2011-12-09 08:00 |  |  |
| 90 | 2.16.16 | R3 Admin Meeting 16 | 1h | 2011-12-16 08:00 | 2011-12-16 09:00 |  |  |  | 32d | start no earlier than 2011-12-16 08:00 |  |  |
| 91 | 2.16.17 | R3 Admin Meeting 17 | 1h | 2011-12-23 08:00 | 2011-12-23 09:00 |  |  |  | 27d | start no earlier than 2011-12-23 08:00 |  |  |
| 92 | 2.16.18 | R3 Admin Meeting 18 | 1h | 2011-12-30 08:00 | 2011-12-30 09:00 |  |  |  | 22d | start no earlier than 2011-12-30 08:00 |  |  |
| 93 | 2.16.19 | R3 Admin Meeting 19 | 1h | 2012-01-06 08:00 | 2012-01-06 09:00 |  |  |  | 17d | start no earlier than 2012-01-06 08:00 |  |  |
| 94 | 2.16.20 | R3 Admin Meeting 20 | 1h | 2012-01-13 08:00 | 2012-01-13 09:00 |  |  |  | 12d | start no earlier than 2012-01-13 08:00 |  |  |
| 95 | 2.16.21 | R3 Admin Meeting 21 | 1h | 2012-01-20 08:00 | 2012-01-20 09:00 |  |  |  | 7d | start no earlier than 2012-01-20 08:00 |  |  |
| 96 | 2.16.22 | R3 Admin Meeting 22 | 1h | 2012-01-27 08:00 | 2012-01-27 09:00 |  |  |  | 0d | start no earlier than 2012-01-27 08:00 |  |  |
| 97 | 2.17 | Communicate cut-over plan | 1h | 2011-11-18 16:00 | 2011-11-18 17:00 | 29 |  |  | 49.12d |  | Core | 1h |
| 98 | 2.18 | Schedule Lessons Learned meeting | 1h | 2012-01-11 08:00 | 2012-01-11 09:00 | 279FS+25d |  |  | 12d |  | PM | 1h |

| ID | WBS | Task | Duration | Start | Finish | Predecessors | Complete | Resources | Work | Actual work |
| --- | --- | --- | --- | --- | --- | --- | --- | --- | --- | --- |
| 99 | 3 | **Develop SAP SP Unit Test db** | 35.83d | 2011-08-29 08:00 A | 2011-10-17 15:40 A |  | 100% |  | 332h | 332h |
| 100 | 3.1 | Schedule meeting with developer team lead | 1h | 2011-09-15 10:40 A | 2011-09-15 11:40 A | 12 | 100% | PM | 1h | 1h |
| 101 | 3.2 | Define reuirements | 1d | 2011-08-29 08:00 A | 2011-08-29 17:00 A |  | 100% | PM | 8h | 8h |
| 102 | 3.3 | SAP SP Unit Test db meeting | 2h | 2011-09-19 11:40 A | 2011-09-19 14:40 A | 100FS+2d | 100% | PM | 2h | 2h |
| 103 | 3.4 | Assign developer | 1h | 2011-09-19 14:40 A | 2011-09-19 15:40 A | 102 | 100% | IDD | 1h | 1h |
| 104 | 3.5 | Develop SAP SP Unit db | 20d | 2011-09-19 15:40 A | 2011-10-17 15:40 A | 103 | 100% | TestC - HR; TestC - FI | 320h | 320h |
| 105 | 4 | **Test Planning** | 37.5d | 2011-09-09 09:00 A | 2011-11-01 14:00 A |  | 100% |  | 1485h | 1485h |
| 106 | 4.1 | Define, document, communicate test case management procedure - templates, process, … | 1d | 2011-09-09 09:00 A | 2011-09-12 09:00 A | 2 | 100% | QA | 8h | 8h |
| 107 | 4.2 | **Unit Test Planning (UT)** | 32.33d | 2011-09-12 09:00 A | 2011-10-26 11:40 A | 106 | 100% |  | 117h | 117h |
| 108 | 4.2.1 | Execute SAP Transaction/Program usage report | 2d | 2011-09-12 09:00 A | 2011-09-14 09:00 A | 2 | 100% | R3 | 16h | 16h |
| 109 | 4.2.2 | Mirge usage report into SAP SP Unit Test db | 4h | 2011-10-17 15:40 A | 2011-10-18 10:40 A | 99 | 100% | R3 | 4h | 4h |
| 110 | 4.2.3 | Determine transactions / reports to be tested | 5d | 2011-10-18 10:40 A | 2011-10-25 10:40 A | 109 | 100% | TestC - FI; TestC-HR | 80h | 80h |
| 111 | 4.2.4 | Update SAP SP Unit Test db | 1d | 2011-10-25 10:40 A | 2011-10-26 10:40 A | 110 | 100% | TestC - FI; TestC-HR | 16h | 16h |
| 112 | 4.2.5 | Publish Unit test plan | 1h | 2011-10-26 10:40 A | 2011-10-26 11:40 A | 111 | 100% | PM | 1h | 1h |
| 113 | 4.3 | **Update Quality Center (QC) test script catalogs** | 31d | 2011-09-12 09:00 A | 2011-10-25 09:00 A | 106 | 100% |  | 1360h | 1360h |
| 114 | 4.3.1 | Convert SIT/UAT cases into QC | 20d | 2011-09-12 09:00 A | 2011-10-10 09:00 A |  | 100% | QA | 160h | 160h |
| 115 | 4.3.2 | Review transaction / report log for new items | 5d | 2011-09-12 09:00 A | 2011-09-19 09:00 A |  | 100% | TestC - FI; TestC-HR | 80h | 80h |
| 116 | 4.3.3 | Update test script catalog with new transactions / reports | 5d | 2011-09-19 09:00 A | 2011-09-26 09:00 A | 115 | 100% | TestC - FI; TestC-HR | 80h | 80h |
| 117 | 4.3.4 | Review test script catalog for missing / old test scripts | 2d | 2011-09-26 09:00 A | 2011-09-28 09:00 A | 116 | 100% | TestC - FI; TestC-HR | 32h | 32h |
| 118 | 4.3.5 | Create new / update old test scripts | 30d | 2011-09-12 09:00 A | 2011-10-24 09:00 A | 106 | 100% | TestC - FI; TestC-HR | 480h | 480h |
| 119 | 4.3.6 | Convert test cases to new template | 30d | 2011-09-12 09:00 A | 2011-10-24 09:00 A | 106 | 100% | TestC - FI; TestC-HR | 480h | 480h |
| 120 | 4.3.7 | Financial Team confirms completeness of test script catalog | 1d | 2011-10-24 09:00 A | 2011-10-25 09:00 A | 119 | 100% | FIN-Team | 8h | 8h |
| 121 | 4.3.8 | Logistics Team confirms completeness of test script catalog | 1d | 2011-10-24 09:00 A | 2011-10-25 09:00 A | 119 | 100% | Log-Team | 8h | 8h |
| 122 | 4.3.9 | EHS Team confirms completeness of test script catalog | 1d | 2011-10-24 09:00 A | 2011-10-25 09:00 A | 119 | 100% | EHS-Team | 8h | 8h |
| 123 | 4.3.10 | HR-Payroll Team confirms completeness of test script catalog | 1d | 2011-10-24 09:00 A | 2011-10-25 09:00 A | 119 | 100% | HRP-Team | 8h | 8h |
| 124 | 4.3.11 | Provide QA w/ FI/LOG/EHS QC user list | 1d | 2011-10-24 09:00 A | 2011-10-25 09:00 A | 119 | 100% | TestC-FI | 8h | 8h |
| 125 | 4.3.12 | Provide QA w/ HRP QC user list | 1d | 2011-10-24 09:00 A | 2011-10-25 09:00 A | 119 | 100% | TestC-HR | 8h | 8h |

| ID | WBS | Task | Duration | Start | Finish | Predecessors | Complete | Remaining | Total slack | Free slack | Resources | Work | Actual work |
| --- | --- | --- | --- | --- | --- | --- | --- | --- | --- | --- | --- | --- | --- |
| 126 | 4.4 | **Systems Integration Test Planning (SIT)** | 36.5d | 2011-09-12 09:00 A | 2011-11-01 14:00 A | 113SS | 100% |  |  |  |  |  |  |
| 127 | 4.4.1 | Send UA test script calatlog to business owners | 4h | 2011-09-12 09:00 A | 2011-09-12 14:00 A |  | 100% |  |  |  |  |  |  |
| 128 | 4.4.2 | Function Test Leads meet with Functional Areas to review/plan testing (repetitive) | 30d | 2011-09-12 14:00 A | 2011-10-24 14:00 A | 127 | 100% |  |  |  |  |  |  |
| 129 | 4.4.3 | Define business scenarios/tests to be used in SIT (add to QC test lab) | 30d | 2011-09-12 14:00 A | 2011-10-24 14:00 A | 127 | 100% |  |  |  |  |  |  |
| 130 | 4.4.4 | Update business scenarios as required | 2d | 2011-10-24 14:00 A | 2011-10-26 14:00 A | 129 | 100% |  |  |  |  |  |  |
| 131 | 4.4.5 | QA review of test lab selections | 2d | 2011-10-26 14:00 A | 2011-10-28 14:00 A | 130 | 100% |  |  |  |  |  |  |
| 132 | 4.4.6 | **Functional Teams confirm test plan** | 1d | 2011-10-26 14:00 A | 2011-10-27 14:00 A | 130 | 100% |  |  |  |  |  |  |
| 133 | 4.4.6.1 | Financial Team confirms completeness of business scenarios | 1d | 2011-10-26 14:00 A | 2011-10-27 14:00 A | 130 | 100% |  |  |  |  |  |  |
| 134 | 4.4.6.2 | Logistics Team confirms completeness of business scenarios | 1d | 2011-10-26 14:00 A | 2011-10-27 14:00 A | 130 | 100% |  |  |  |  |  |  |
| 135 | 4.4.6.3 | EHS Team confirms completeness of business scenarios | 1d | 2011-10-26 14:00 A | 2011-10-27 14:00 A | 130 | 100% |  |  |  |  |  |  |
| 136 | 4.4.6.4 | HR-Payroll Team confirms completeness of business scenarios | 1d | 2011-10-26 14:00 A | 2011-10-27 14:00 A | 130 | 100% |  |  |  |  |  |  |
| 137 | 4.4.7 | QA confirms completeness of business scenarios | 1d | 2011-10-26 14:00 A | 2011-10-27 14:00 A | 130 | 100% |  |  |  |  |  |  |
| 138 | 4.4.8 | Publish SIT Test Schedule | 1d | 2011-10-27 14:00 A | 2011-10-28 14:00 A | 137 | 100% |  |  |  |  |  |  |
| 139 | 4.4.9 | **User Acceptance of SIT Planning** | 2d | 2011-10-28 14:00 A | 2011-11-01 14:00 A | 138 | 100% |  |  |  |  |  |  |
| 140 | 4.4.9.1 | Send UA test script catalog to business owners | 4h | 2011-10-28 14:00 A | 2011-10-31 09:00 A |  | 100% |  |  |  |  |  |  |
| 141 | 4.4.9.2 | Business analysts update test script catalogs | 4h | 2011-11-01 09:00 A | 2011-11-01 14:00 A | 140FS+1d | 100% |  |  |  |  |  |  |
| 142 | 5 | **System Admin Preparation** | 15.5d | 2011-09-21 10:40 A | 2011-10-12 15:40 | 15FS+10d | 66% | 5.34d | 78.29d | 0d |  | 140h | 100h |
| 143 | 5.1 | Review and update action log from previous year | 1d | 2011-09-21 10:40 A | 2011-09-22 10:40 A |  | 100% |  |  |  | PM; R3; ABAP Lead | 24h | 24h |
| 144 | 5.2 | Download HRP SP OSS Note Lists (604-40/605-17) | 1d | 2011-09-21 10:40 A | 2011-09-22 10:40 A |  | 100% |  |  |  | PM; BA1 | 16h | 16h |
| 145 | 5.3 | Format SP OSS Note Lists into a single spreadsheet and post on wiki | 4h | 2011-09-22 10:40 A | 2011-09-22 15:40 A | 144 | 100% |  |  |  | BA1 | 4h | 4h |
| 146 | 5.4 | Solution Manager Update - SM1 sandbox (SPS Level 21 -> SPS Level 24) | 3d | 2011-09-21 10:40 A | 2011-09-26 10:40 A |  | 100% |  |  |  | R3-4 | 24h | 24h |
| 147 | 5.5 | Solution Manager Update - SM2 dev/test (SPS Level 21 -> SPS Level 24) | 3d | 2011-09-26 10:40 | 2011-09-29 10:40 | 146 |  |  | 85.79d | 0d | R3-4 | 24h |  |
| 148 | 5.6 | Solution Manager Update - PSM production (SPS Level 21 -> SPS Level 24) | 2d | 2011-09-29 10:40 | 2011-10-03 10:40 | 147 |  |  | 85.79d |  | R3-4 | 16h |  |
| 149 | 5.7 | Produce Side Effects Report | 2d | 2011-10-10 15:40 A | 2011-10-12 15:40 A | 145FS+12d | 100% |  |  |  | R3-1 | 16h | 16h |
| 150 | 5.8 | Download Enh Packs, SP Stacks, SPs | 2d | 2011-10-10 15:40 A | 2011-10-12 15:40 A | 149SS | 100% |  |  |  | R3-2 | 16h | 16h |

| ID | WBS | Task | Type | Duration | Start | Finish | Predecessors | Complete | Remaining | Total slack | Constraint | Calendar | Resources | Work | Actual work |
| --- | --- | --- | --- | --- | --- | --- | --- | --- | --- | --- | --- | --- | --- | --- | --- |
| 151 | 6 | **Practice update (SF7) - SKIP in 2011 - step not needed** |  | 17.5d | 2011-09-26 10:40 A | 2011-10-19 15:40 A | 142SS+3d | 100% |  |  |  |  |  | 140h | 140h |
| 152 | 6.1 | Identify & Prepare practice system |  | 13d | 2011-09-26 10:40 A | 2011-10-13 10:40 A |  | 100% |  |  |  |  | R3-1 | 104h | 104h |
| 153 | 6.2 | Apply SAP kernel update |  | 4h | 2011-10-13 10:40 A | 2011-10-13 15:40 A | 152 | 100% |  |  |  |  | R3-1 | 4h | 4h |
| 154 | 6.3 | Upgrade Oracle db |  | 8h | 2011-10-13 15:40 A | 2011-10-14 15:40 A | 153 | 100% |  |  |  |  | R3-1 | 8h | 8h |
| 155 | 6.4 | Test Install Support Packs (TBD) |  | 3d | 2011-10-14 15:40 A | 2011-10-19 15:40 A | 154 | 100% |  |  |  |  | R3-1 | 24h | 24h |
| 156 | 7 | PS Snapshot for SF3 (10/03/2011) |  | 1d | 2011-10-03 08:00 A | 2011-10-03 17:00 A |  | 100% |  |  | must start on 2011-10-03 08:00 |  |  |  |  |
| 157 | 8 | **Cleanup pending transports (to be moved before freeze)** |  | 15d | 2011-10-13 13:40 A | 2011-11-03 13:40 A | 42FS+20d | 100% |  |  |  |  |  | 224h | 224h |
| 158 | 8.1 | Create transport list |  | 1d | 2011-10-13 13:40 A | 2011-10-14 13:40 A | 6 | 100% |  |  |  |  | TransC | 8h | 8h |
| 159 | 8.2 | Determine status and plan for each |  | 3d | 2011-10-13 13:40 A | 2011-10-18 13:40 A | 6 | 100% |  |  |  |  | TransC | 24h | 24h |
| 160 | 8.3 | Execute pending transport plan |  | 12d | 2011-10-18 13:40 A | 2011-11-03 13:40 A | 159 | 100% |  |  |  |  | R3; TransC | 192h | 192h |
| 161 | 9 | **Refresh Staging Environment (SF3)** |  | 7.75d | 2011-10-07 08:00 A | 2011-10-18 15:00 |  | 99% | 0d | 0d |  |  |  | 55h | 55h |
| 162 | 9.1 | Notify SAP Support Teams of Pending SF3 Outage |  | 1h | 2011-10-07 08:00 A | 2011-10-07 09:00 A | 156FS+3d | 100% |  |  |  |  | R3-1 | 1h | 1h |
| 163 | 9.2 | SF3 out of service/SF8 becomes system for OSS staging environment | milestone | 0h | 2011-10-08 17:00 A | 2011-10-08 17:00 A | 156FS+15d | 100% |  |  |  | 24 Hours |  |  |  |
| 164 | 9.3 | Holiday (Columbus Day) | milestone | 0h | 2011-10-10 17:00 A | 2011-10-10 17:00 A |  | 100% |  |  | start no earlier than 2011-10-10 17:00 |  |  |  |  |
| 165 | 9.4 | Refresh with 10/04/2010 PS1 Snapshot |  | 4d | 2011-10-10 08:00 A | 2011-10-13 17:00 A | 163 | 100% |  |  |  |  | R3 | 32h | 32h |
| 166 | 9.5 | Import PS1/SF3 Transport Gap (10/5-10/15) |  | 4h | 2011-10-14 08:00 A | 2011-10-14 12:00 A | 165 | 100% |  |  |  |  | R3-1 | 4h | 4h |
| 167 | 9.6 | Execute R3 Action Log |  | 4h | 2011-10-14 13:00 A | 2011-10-14 17:00 A | 166 | 100% |  |  |  |  | R3 | 4h | 4h |
| 168 | 9.7 | Unlock Action Log participants |  | 1h | 2011-10-17 08:00 A | 2011-10-17 09:00 A | 167 | 100% |  |  |  |  | R3-2 | 1h | 1h |
| 169 | 9.8 | Execute Refresh Action Log |  | 4h | 2011-10-17 09:00 A | 2011-10-17 14:00 A | 168 | 100% |  |  |  |  | All | 4h | 4h |
| 170 | 9.9 | Scramble sensitive data <hold off scrambling - perform after py sim run post SF3 upgrade> | milestone | 0d | 2011-10-17 14:00 | 2011-10-17 14:00 | 169 |  |  | 0d |  |  |  |  |  |
| 171 | 9.10 | Execute pre-upgrade payroll simulation run (ZM) & store results (for comparison) |  | 1d | 2011-10-17 14:00 A | 2011-10-18 14:00 A | 170 | 100% |  |  |  |  | HRP | 8h | 8h |
| 172 | 9.11 | Lock Action Log participants |  | 1h | 2011-10-18 14:00 A | 2011-10-18 15:00 A | 171 | 100% |  |  |  |  | R3-2 | 1h | 1h |
| 173 | 10 | **Obtain Final Support Pack** |  | 2d | 2011-10-13 08:00 A | 2011-10-14 17:00 A |  | 100% |  |  |  |  |  | 16h | 16h |
| 174 | 10.1 | October support pack available from SAP | milestone | 1d | 2011-10-13 08:00 A | 2011-10-13 17:00 A |  | 100% |  |  | start no earlier than 2011-10-13 08:00 |  | SAP | 8h | 8h |
| 175 | 10.2 | Download support pack & most current SAP kernel patch |  | 1d | 2011-10-14 08:00 A | 2011-10-14 17:00 A | 174 | 100% |  |  |  |  | R3 | 8h | 8h |
| 176 | 11 | PS1 Snapshot for Test Environment (SH1 - 10/17/2011) |  | 1d | 2011-10-17 08:00 A | 2011-10-17 17:00 A |  | 100% |  |  | must start on 2011-10-17 08:00 |  |  |  |  |

| ID | WBS | Task | Type | Duration | Start | Finish | Predecessors | Complete | Calendar | Resources | Work | Actual work |
| --- | --- | --- | --- | --- | --- | --- | --- | --- | --- | --- | --- | --- |
| 177 | 12 | **Update Pre-staging Environment (SFK) - skipped 2011** |  | 4d | 2011-10-18 08:00 A | 2011-10-21 17:00 A | 173FS+1d | 100% |  |  | 20h | 20h |
| 178 | 12.1 | Apply SAP kernel update (most current version) |  | 4h | 2011-10-18 08:00 A | 2011-10-18 12:00 A |  | 100% | 24 Hours | R3-1 | 4h | 4h |
| 179 | 12.2 | Upgrade Oracle db | milestone | 0h | 2011-10-18 12:00 A | 2011-10-18 12:00 A | 178 | 100% | 24 Hours | R3-1 |  |  |
| 180 | 12.3 | Install Support packages ( Enh 5 + SP Stacks 5 + SP 14-17) |  | 36h | 2011-10-18 12:00 A | 2011-10-20 00:00 A | 179 | 100% | 24 Hours |  |  |  |
| 181 | 12.4 | Update ancillary systems (Portal - SPS 7; PI-ADS - OSS Notes) |  | 1d | 2011-10-20 08:00 A | 2011-10-20 17:00 A | 180 | 100% |  | R3-3; R3-4 | 16h | 16h |
| 182 | 12.5 | Validate security infrastructure (SNC) |  | 2d | 2011-10-20 08:00 A | 2011-10-21 17:00 A | 180 | 100% |  |  |  |  |
| 183 | 12.6 | Validate SAPGui interactions |  | 2d | 2011-10-20 08:00 A | 2011-10-21 17:00 A | 180 | 100% |  |  |  |  |
| 184 | 12.7 | Validate basic SAP functions work |  | 2d | 2011-10-20 08:00 A | 2011-10-21 17:00 A | 180 | 100% |  |  |  |  |
| 185 | 12.8 | SFK updated | milestone | 0h | 2011-10-20 17:00 A | 2011-10-20 17:00 A | 181 | 100% |  |  |  |  |
| 186 | 13 | **Update Staging Environment (SF3)** |  | 5d | 2011-10-17 08:00 A | 2011-10-21 17:00 A | 173 | 100% |  |  | 125h | 125h |
| 187 | 13.1 | Apply SAP kernel update (most current version) |  | 2h | 2011-10-17 08:00 A | 2011-10-17 10:00 A | 173 | 100% |  | R3-1 | 2h | 2h |
| 188 | 13.2 | Install Support packages (Enh 5 + SP Stacks 5 + SP 14-17) |  | 22h | 2011-10-17 10:00 A | 2011-10-18 08:00 A | 187 | 100% | 24 Hours | R3-1 | 6h | 6h |
| 189 | 13.3 | Upgrade Oracle db |  | 8h | 2011-10-18 08:00 A | 2011-10-18 17:00 A | 188 | 100% | 24 Hours | R3-2 | 8h | 8h |
| 190 | 13.4 | Back up SF3 |  | 2h | 2011-10-19 08:00 A | 2011-10-19 10:00 A | 189 | 100% |  |  |  |  |
| 191 | 13.5 | Update BSI ( most current TUBs) |  | 2h | 2011-10-17 10:00 A | 2011-10-17 12:00 A | 188SS | 100% | 24 Hours | R3-1 | 2h | 2h |
| 192 | 13.6 | Update ancillary systems (Portal - SPS 7; PI-ADS - OSS Notes) |  | 1d | 2011-10-18 08:00 A | 2011-10-18 17:00 A | 188 | 100% |  | R3-1 [300%] | 24h | 24h |
| 193 | 13.7 | Produce SPAU report, Apply OSS notes |  | 1d | 2011-10-18 08:00 A | 2011-10-18 17:00 A | 188 | 100% |  | R3-4 | 8h | 8h |
| 194 | 13.8 | Post Support pack action log |  | 4h | 2011-10-17 13:00 A | 2011-10-17 17:00 A | 191 | 100% |  | R3-3 | 4h | 4h |
| 195 | 13.9 | Validate - external interfaces ITS, jco, mitid, fax. |  | 6h | 2011-10-18 08:00 A | 2011-10-18 15:00 A | 194 | 100% |  | R3-3 | 6h | 6h |
| 196 | 13.10 | Unlock Developers involved in SPAU analysis |  | 1h | 2011-10-18 15:00 A | 2011-10-18 16:00 A | 195 | 100% |  | R3-2 | 1h | 1h |
| 197 | 13.11 | Check, decide, apply MIT mods or use enhancement framework |  | 2d | 2011-10-19 08:00 A | 2011-10-20 17:00 A | 195FS+1d | 100% | 24 Hours | ABAP | 16h | 16h |
| 198 | 13.12 | SAP developer functionality validation |  | 2d | 2011-10-19 08:00 A | 2011-10-20 17:00 A | 197SS | 100% |  | ABAP [200%] | 32h | 32h |
| 199 | 13.13 | Execute post-upgrade payroll simulation run (ZM) & compare results |  | 1d | 2011-10-21 08:00 A | 2011-10-21 17:00 A | 197 | 100% |  | HRP | 8h | 8h |
| 200 | 13.14 | Execute post-upgrade DW extracts (limited testing - key extracts) |  | 1d | 2011-10-21 08:00 A | 2011-10-21 17:00 A | 197 | 100% |  | DW | 8h | 8h |
| 201 | 13.15 | SF3 updated | milestone | 0h | 2011-10-21 17:00 A | 2011-10-21 17:00 A | 200 | 100% |  |  |  |  |
| 202 | 14 | Development freeze begins (non-SP development is put on hold) | milestone | 0h | 2011-10-24 17:00 A | 2011-10-24 17:00 A | 186FS+1d | 100% |  |  |  |  |
| 203 | 15 | Sync up SF8 w/ PS1 transports |  | 1d | 2011-10-25 08:00 A | 2011-10-25 17:00 A | 202 | 100% |  | R3-1 | 8h | 8h |

Notes:
- 178: Allow for one hour installation time.
- 180: Allow for twekve hours.
- 181: R3 needs to review security notes related to PI/ADS components. / Application of SPS 6 to Portal in process (R3-4).
- 200: Cost element and profit center groups : ZWHCEHI / Payroll results: ZWHPAYROLL_RESULTS_NEW / Overhead: ZWHGETTE, ZWHOHSHT, ZWHOHRT, ZWHOHCRD, ZWHOHBAS, ZWHCTLGN

| ID | WBS | Task | Type | Duration | Start | Finish | Predecessors | Complete | Calendar | Resources | Work | Actual work |
| --- | --- | --- | --- | --- | --- | --- | --- | --- | --- | --- | --- | --- |
| 204 | 16 | **Update Development Environment (SF2)** |  | 3d | 2011-10-24 17:00 A | 2011-10-27 17:00 A | 202 | 100% |  |  | 79h | 79h |
| 205 | 16.1 | Apply SAP kernel update (most current version) |  | 4h | 2011-10-24 17:00 A | 2011-10-24 21:00 A |  | 100% | 24 Hours | R3-1 | 4h | 4h |
| 206 | 16.2 | Install Support packages (Enh 5 + SP Stacks 5 + SP 14-17/604 SP 40) |  | 24h | 2011-10-24 17:00 A | 2011-10-25 17:00 A |  | 100% | 24 Hours | R3-1 | 24h | 24h |
| 207 | 16.3 | Apply BSI Tax Factory Update |  | 2h | 2011-10-26 08:00 A | 2011-10-26 10:00 A | 206 | 100% | 24 Hours | R3-1 | 2h | 2h |
| 208 | 16.4 | Upgrade ERP Oracle db |  | 8h | 2011-10-26 10:00 A | 2011-10-26 18:00 A | 207 | 100% | 24 Hours | R3-4 | 8h | 8h |
| 209 | 16.5 | Back up database |  | 6h | 2011-10-26 18:00 A | 2011-10-27 00:00 A | 208 | 100% | 24 Hours | SO | 6h | 6h |
| 210 | 16.6 | Import transports from SF3 |  | 2h | 2011-10-27 08:00 A | 2011-10-27 10:00 A | 209 | 100% | 24 Hours | R3-1 | 2h | 2h |
| 211 | 16.7 | **Upgrade Portal (JP3) - skip2011** |  | 1d | 2011-10-27 08:00 A | 2011-10-27 17:00 A | 209SS | 100% |  |  | 14h | 14h |
| 212 | 16.7.1 | Apply SPS 7 |  | 6h | 2011-10-27 08:00 A | 2011-10-27 15:00 A |  | 100% |  | R3-4 | 6h | 6h |
| 213 | 16.7.2 | Upgrade Portal Oracle db |  | 8h | 2011-10-27 08:00 A | 2011-10-27 17:00 A |  | 100% |  | R3-4 | 8h | 8h |
| 214 | 16.8 | **Upgrade PI/ADS System (J11)** |  | 1d | 2011-10-27 08:00 A | 2011-10-27 17:00 A | 209SS | 100% |  |  | 15h | 15h |
| 215 | 16.8.1 | Upgrade kernel |  | 1h | 2011-10-27 08:00 A | 2011-10-27 09:00 A |  | 100% |  | R3-3 | 1h | 1h |
| 216 | 16.8.2 | Apply SPS 7 |  | 6h | 2011-10-27 08:00 A | 2011-10-27 15:00 A |  | 100% |  | R3-3 | 6h | 6h |
| 217 | 16.8.3 | Upgrade PI/ADS Oracle db (J01) |  | 8h | 2011-10-27 08:00 A | 2011-10-27 17:00 A |  | 100% |  | R3-3 | 8h | 8h |
| 218 | 16.9 | Execute action log (add updates if necessary) |  | 4h | 2011-10-27 10:00 A | 2011-10-27 15:00 A | 210 | 100% |  | R3-1 | 4h | 4h |
| 219 | 16.10 | SF2 updated | milestone | 0h | 2011-10-27 15:00 A | 2011-10-27 15:00 A | 218 | 100% |  |  |  |  |
| 220 | 17 | **Zuttreq updates** |  | 0.12d | 2011-10-28 08:00 A | 2011-10-28 09:00 A | 204 | 100% |  |  | 2h | 2h |
| 221 | 17.1 | Change target system for transport layer |  | 1h | 2011-10-28 08:00 A | 2011-10-28 09:00 A |  | 100% |  | R3-1 | 1h | 1h |
| 222 | 17.2 | Change target system in Zuttreq |  | 1h | 2011-10-28 08:00 A | 2011-10-28 09:00 A |  | 100% |  | ABAP Lead | 1h | 1h |
| 223 | 18 | **Unit Test Execution (performed in SF2)** |  | 6d | 2011-10-28 08:00 A | 2011-11-04 17:00 A | 204 | 100% |  |  | 184h | 184h |
| 224 | 18.1 | **Functional Tests** |  | 6d | 2011-10-28 08:00 A | 2011-11-04 17:00 A |  | 100% |  |  | 184h | 184h |
| 225 | 18.1.1 | Financial Unit Tests, Issue identification and retest |  | 6d | 2011-10-28 08:00 A | 2011-11-04 17:00 A |  | 100% |  | FIN | 48h | 48h |
| 226 | 18.1.2 | Logistics Unit Tests, Issue identification and retest |  | 6d | 2011-10-28 08:00 A | 2011-11-04 17:00 A |  | 100% |  | log | 48h | 48h |
| 227 | 18.1.3 | EHS Unit Tests, Issue identification and retest |  | 6d | 2011-10-28 08:00 A | 2011-11-04 17:00 A |  | 100% |  | EHS | 48h | 48h |
| 228 | 18.1.4 | HR-Payroll Unit Tests, Issue identification and retest |  | 6d | 2011-10-28 08:00 A | 2011-11-04 17:00 A |  | 100% |  | HRP [83.3%] | 40h | 40h |
| 229 | 18.2 | All functional teams ok environment and move to SIT |  | 4h | 2011-11-04 13:00 A | 2011-11-04 17:00 A | 224FF | 100% |  |  |  |  |
| 230 | 18.3 | Unit test complete | milestone | 0h | 2011-11-04 17:00 A | 2011-11-04 17:00 A | 229 | 100% |  |  |  |  |

| ID | WBS | Task | Type | Duration | Start | Finish | Predecessors | Complete | Calendar | Resources | Work | Actual work |
| --- | --- | --- | --- | --- | --- | --- | --- | --- | --- | --- | --- | --- |
| 231 | 19 | **Refresh Test Environment (SH1)** |  | 7.25d | 2011-10-19 08:00 A | 2011-10-28 10:00 A | 197SS | 100% |  |  | 104h | 104h |
| 232 | 19.1 | Pre-update DW extracts (store for comparisons - from PS1) |  | 4h | 2011-10-19 08:00 A | 2011-10-19 12:00 A |  | 100% |  | DW | 4h | 4h |
| 233 | 19.2 | Confirm/Setup/update gateway components for new test system |  | 4h | 2011-10-19 08:00 A | 2011-10-19 12:00 A |  | 100% |  | IDD | 4h | 4h |
| 234 | 19.3 | Refresh with 10/17/2010 PS1 Snapshot |  | 30h | 2011-10-19 08:00 A | 2011-10-24 15:00 A |  | 100% | 24 Hours | OIS [320%] | 96h | 96h |
| 235 | 19.4 | Post Restore Activities |  | 2d | 2011-10-24 15:00 A | 2011-10-26 15:00 A | 234 | 100% |  |  |  |  |
| 236 | 19.5 | Import PS1/SH1 Transport Gap (10/19-11/5) |  | 4h | 2011-10-26 15:00 A | 2011-10-27 10:00 A | 235 | 100% |  |  |  |  |
| 237 | 19.6 | Execute R3 Action Log |  | 4h | 2011-10-27 10:00 A | 2011-10-27 15:00 A | 236 | 100% |  |  |  |  |
| 238 | 19.7 | Execute Refresh Action Log |  | 4h | 2011-10-27 15:00 A | 2011-10-28 10:00 A | 237 | 100% |  |  |  |  |
| 239 | 20 | **Update Test Environment (SH1)** |  | 5.25d | 2011-10-28 17:00 A | 2011-11-07 10:00 A | 204FS+1d | 100% |  |  | 67h | 67h |
| 240 | 20.1 | Apply SAP kernel update |  | 2h | 2011-10-28 17:00 A | 2011-10-28 19:00 A | 238 | 100% | 24 Hours | R3-1 | 2h | 2h |
| 241 | 20.2 | Install Support packages (Enh 5 + SP Stacks 5 + SP 14-17) |  | 12h | 2011-10-28 19:00 A | 2011-10-29 07:00 A | 240 | 100% | 24 Hours | R3-1 | 12h | 12h |
| 242 | 20.3 | Apply BSI Tax Factory Update |  | 2h | 2011-10-29 07:00 A | 2011-10-29 09:00 A | 241 | 100% | 24 Hours | R3-1 | 2h | 2h |
| 243 | 20.4 | Import transports from SF3 |  | 2h | 2011-10-29 09:00 A | 2011-10-29 11:00 A | 242 | 100% | 24 Hours | R3-1 | 2h | 2h |
| 244 | 20.5 | Upgrade Oracle db |  | 8h | 2011-10-29 11:00 A | 2011-10-29 19:00 A | 243 | 100% | 24 Hours | R3-4 | 8h | 8h |
| 245 | 20.6 | Back up database |  | 6h | 2011-10-29 19:00 A | 2011-10-30 01:00 A | 244 | 100% | 24 Hours | SO | 6h | 6h |
| 246 | 20.7 | Execute post support pack action log (add updates if necessary) |  | 4h | 2011-10-31 08:00 A | 2011-10-31 12:00 A | 245 | 100% |  | R3 | 4h | 4h |
| 247 | 20.8 | Import transports from SF2 |  | 2h | 2011-11-04 17:00 A | 2011-11-04 19:00 A | 230 | 100% | 24 Hours | R3-1 | 2h | 2h |
| 248 | 20.9 | Import Production Transports from 11/4 |  | 2h | 2011-11-07 08:00 A | 2011-11-07 10:00 A | 247 | 100% |  |  |  |  |
| 249 | 20.10 | DW Schedule Extract Jobs |  | 1h | 2011-10-31 13:00 A | 2011-10-31 14:00 A | 246 | 100% |  |  |  |  |
| 250 | 20.11 | **Upgrade Portal (JP5)** |  | 1d | 2011-10-31 08:00 A | 2011-10-31 17:00 A |  | 100% |  |  | 14h | 14h |
| 251 | 20.11.1 | Apply SPS 7 |  | 6h | 2011-10-31 08:00 A | 2011-10-31 15:00 A |  | 100% |  | R3-4 | 6h | 6h |
| 252 | 20.11.2 | Upgrade Portal Oracle db |  | 8h | 2011-10-31 08:00 A | 2011-10-31 17:00 A |  | 100% |  | R3-4 | 8h | 8h |
| 253 | 20.12 | **Upgrade PI/ADS System** |  | 1d | 2011-10-31 08:00 A | 2011-10-31 17:00 A |  | 100% |  |  | 15h | 15h |
| 254 | 20.12.1 | Update kernel |  | 1h | 2011-10-31 08:00 A | 2011-10-31 09:00 A |  | 100% |  | R3-3 | 1h | 1h |
| 255 | 20.12.2 | Apply SPS 7 |  | 6h | 2011-10-31 08:00 A | 2011-10-31 15:00 A |  | 100% |  | R3-3 | 6h | 6h |
| 256 | 20.12.3 | Upgrade PI/ADS Oracle db |  | 8h | 2011-10-31 08:00 A | 2011-10-31 17:00 A |  | 100% |  | R3-3 | 8h | 8h |
| 257 | 21 | Production Transport Freeze Begins (last transports allowed into PS1) | milestone | 0d | 2011-11-07 10:00 A | 2011-11-07 10:00 A | 239 | 100% |  |  |  |  |

| ID | WBS | Task | Type | Duration | Start | Finish | Predecessors | Complete | Remaining | Total slack | Free slack | Constraint | Calendar | Resources | Work | Actual work |
| --- | --- | --- | --- | --- | --- | --- | --- | --- | --- | --- | --- | --- | --- | --- | --- | --- |
| 258 | 22 | **Execute System Integration Tests (SH1)** |  | 15.5d | 2011-11-07 08:00 A | 2011-11-28 12:00 | 223 | 76% | 3.79d | 4.5d | 0d |  |  |  | 228h | 178h |
| 259 | 22.1 | Holiday (Veterans Day) | milestone | 0d | 2011-11-07 10:00 A | 2011-11-07 10:00 A | 257 | 100% |  |  |  |  |  |  |  |  |
| 260 | 22.2 | Post GUI message on prod support env indicating its use (SH2) |  | 1h | 2011-11-07 08:00 A | 2011-11-07 09:00 A |  | 100% |  |  |  |  |  |  |  |  |
| 261 | 22.3 | Execute Payroll comparison run |  | 5d | 2011-11-07 08:00 A | 2011-11-11 17:00 A |  | 100% |  |  |  |  |  | HRP | 40h | 40h |
| 262 | 22.4 | Execute data warehouse extracts |  | 1d | 2011-11-07 08:00 A | 2011-11-07 17:00 A | 261SS | 100% |  |  |  |  |  | DW | 8h | 8h |
| 263 | 22.5 | Execute FIN TB |  | 1d | 2011-11-07 08:00 A | 2011-11-07 17:00 A | 261SS | 100% |  |  |  |  |  | FIN-1 | 8h | 8h |
| 264 | 22.6 | Analyze data warehouse extracts comparison |  | 1d | 2011-11-08 08:00 A | 2011-11-08 17:00 A | 263 | 100% |  |  |  |  |  | DW | 8h | 8h |
| 265 | 22.7 | Analyze payroll comparison run |  | 3d | 2011-11-14 08:00 A | 2011-11-16 17:00 A | 261 | 100% |  |  |  |  |  | HRP | 24h | 24h |
| 266 | 22.8 | Financial Close (month of October) |  | 1d | 2011-11-14 08:00 A | 2011-11-14 17:00 A | 261 | 100% |  |  |  |  |  | FIN | 8h | 8h |
| 267 | 22.9 | Execute Automated Testing |  | 2d | 2011-11-14 08:00 A | 2011-11-15 17:00 A | 261 | 100% |  |  |  |  |  | QA-4 | 16h | 16h |
| 268 | 22.10 | Execute General SIT |  | 11d | 2011-11-08 08:00 A | 2011-11-22 17:00 | 262 | 75% | 2.75d | 4.5d | 0d |  |  | All | 88h | 66h |
| 269 | 22.11 | Issue Retesting |  | 2d | 2011-11-23 08:00 | 2011-11-24 17:00 | 268 |  |  | 6d |  |  |  | All | 16h |  |
| 270 | 22.12 | Execute pre-update validation testing |  | 1d | 2011-11-24 08:00 | 2011-11-24 17:00 | 268FS+1d |  |  | 4.5d | 0d |  |  | Bus-Val | 8h |  |
| 271 | 22.13 | System Integration Test sign-off |  | 4h | 2011-11-25 08:00 | 2011-11-25 12:00 | 270 |  |  | 4.5d | 0d |  |  | All | 4h |  |
| 272 | 22.14 | SIT complete | milestone | 0h | 2011-11-25 12:00 | 2011-11-25 12:00 | 271 |  |  | 4.5d | 0d |  |  |  |  |  |
| 273 | 22.15 | Final preparation work |  | 1d | 2011-11-25 13:00 | 2011-11-28 12:00 | 272 |  |  | 4.5d |  |  |  |  |  |  |
| 274 | 23 | **Pre-cutover weekend activities** |  | 3.25d | 2011-11-18 13:00 A | 2011-11-23 15:00 | 279SS-8d | 25% | 2.44d | 46.38d |  |  |  |  | 4h | 1h |
| 275 | 23.1 | Expand prod disc space to accommodate Enh Pack load |  | 1h | 2011-11-18 13:00 A | 2011-11-18 14:00 A |  | 100% |  |  |  |  |  | OIS | 1h | 1h |
| 276 | 23.2 | System message put out on SAP GUI |  | 1h | 2011-11-23 14:00 | 2011-11-23 15:00 | 275FS+3d |  |  | 46.38d |  |  |  | R3-1 | 1h |  |
| 277 | 23.3 | System message put out on SAPWeb & ESS&insideMIT pages |  | 1h | 2011-11-23 14:00 | 2011-11-23 15:00 | 275FS+3d |  |  | 46.38d |  |  |  | IDD | 1h |  |
| 278 | 23.4 | Send outage headsup message to community |  | 1h | 2011-11-23 14:00 | 2011-11-23 15:00 | 275FS+3d |  |  | 46.38d |  |  |  | PM | 1h |  |
| 279 | 24 | **Cutover weekend & Controlled Start** |  | 4.5d | 2011-11-30 12:00 | 2011-12-06 17:00 |  |  |  | 4d | 0d |  |  |  | 4h |  |
| 280 | 24.1 | Update production (detailed weekend cutover plan in a separate document) | milestone | 2d | 2011-11-30 12:00 | 2011-12-01 04:00 | 258FS+6d |  |  | 19.38d | 0d |  | 24 Hours |  |  |  |
| 281 | 24.2 | Production validation |  | 1d | 2011-12-01 12:00 | 2011-12-01 20:00 | 280FS+1d |  |  | 19.38d | 0d |  | 24 Hours | Bus [50%] | 4h |  |
| 282 | 24.3 | Go/No Go approval |  | 1h | 2011-12-01 20:00 | 2011-12-01 21:00 | 281 |  |  | 19.38d | 0d |  | 24 Hours |  |  |  |
| 283 | 24.4 | Updated production available | milestone | 0h | 2011-12-01 21:00 | 2011-12-01 21:00 | 282 |  |  | 4d | 0d |  |  |  |  |  |
| 284 | 24.5 | First Production pay run execution |  | 2d | 2011-12-05 08:00 | 2011-12-06 17:00 | 283FS+1d |  |  | 4d | 0d |  |  |  |  |  |
| 285 | 25 | Freezes End (development & production) | milestone | 0h | 2011-12-06 17:00 | 2011-12-06 17:00 | 284 |  |  | 4d | 0d |  |  |  |  |  |
| 286 | 26 | First Calendar 2012 Payroll |  | 1d | 2011-12-28 08:00 | 2011-12-28 17:00 |  |  |  | 0d |  | must finish on 2011-12-28 17:00 |  |  |  |  |

| ID | WBS | Task | Duration | Start | Finish | Predecessors | Total slack | Free slack |
| --- | --- | --- | --- | --- | --- | --- | --- | --- |
| 287 | 27 | **Post go-live activities** | 33.12d | 2011-12-07 08:00 | 2012-01-23 09:00 |  | 4d |  |
| 288 | 27.1 | Install SAP GUI level 16 on EHS PCs (see RT # 1397279) | 2h | 2011-12-07 08:00 | 2011-12-07 10:00 | 285 | 36.88d |  |
| 289 | 27.2 | SH2 Status Change | 1h | 2011-12-07 08:00 | 2011-12-07 09:00 | 285 | 36.88d | 0d |
| 290 | 27.3 | SH1 Status Change | 1h | 2011-12-07 08:00 | 2011-12-07 09:00 | 285 | 37d |  |
| 291 | 27.4 | SF8 Status Change | 1h | 2011-12-07 08:00 | 2011-12-07 09:00 | 285 | 37d |  |
| 292 | 27.5 | Scramble SF3 | 4h | 2011-12-07 08:00 | 2011-12-07 12:00 | 285 | 36.62d |  |
| 293 | 27.6 | PS1 Snapshot for SF8/SH2 | 1h | 2011-12-21 08:00 | 2011-12-21 09:00 | 285FS+10d | 4d | 0d |
| 294 | 27.7 | SH2 System refresh & update | 10d | 2011-12-21 09:00 | 2012-01-04 09:00 | 293 | 4d | 0d |
| 295 | 27.8 | Zuttreq updates | 1h | 2011-12-07 09:00 | 2011-12-07 10:00 | 289 | 36.88d |  |
| 296 | 27.9 | Change target system in Zuttreq | 1h | 2011-12-07 09:00 | 2011-12-07 10:00 | 289 | 36.88d |  |
| 297 | 27.10 | SF8 System Refresh & Update | 10d | 2012-01-09 09:00 | 2012-01-23 09:00 | 294FS+3d | 4d |  |
